# DESOx_A.2_Příloha_HMG

Schedule from MS Project, 2023-10-06 to 2029-04-09.
CHEMING, a.s.

## Calendars

- Standardní: Mon-Fri 09:00-13:00, 14:00-18:00; Sat-Sun off.

## Schedule

| ID | WBS | Task | Type | Duration | Start | Finish | Predecessors | Total slack | Free slack | Constraint |
| --- | --- | --- | --- | --- | --- | --- | --- | --- | --- | --- |
| 1 | 1 | **Harmonogram / Time schedule** |  | 1436d | 2023-10-06 | 2029-04-09 |  | 0d |  |  |
| 2 | 1.1 | Výběrové řízení / Tender procedure |  | 257d | 2023-10-06 | 2024-09-30 |  | 515d | 0d | finish no earlier than 2024-09-30 |
| 3 | 1.2 | Podpis smlouvy o dílo / Contract signing | milestone | 0d | 2024-10-01 | 2024-10-01 | 2 | 515d | 0d | start no earlier than 2024-10-01 |
| 4 | 1.3 | **Dokumentace / Documentation** |  | 200d | 2024-10-01 | 2025-07-07 |  | 650d |  |  |
| 5 | 1.3.1 | Plánu jakosti / Quality plan |  | 24d | 2024-10-01 | 2024-11-01 | 3 | 1020d |  | start no earlier than 2024-10-01 |
| 6 | 1.3.2 | Příprava dokumentace BD / Basic design preparation |  | 67d | 2024-10-01 | 2025-01-01 | 3 | 515d | 0d | start no earlier than 2024-10-01 |
| 7 | 1.3.3 | Příprava dokumentace DD / Detail design preparation |  | 153d | 2024-12-05 | 2025-07-07 | 6FS-1mo | 844d |  |  |
| 8 | 1.4 | **Staveniště / Construction site** |  | 85d | 2024-11-01 | 2025-02-28 |  | 649d |  |  |
| 9 | 1.4.1 | Předání staveniště / Construction Site handing over | milestone | 0d | 2024-11-01 | 2024-11-01 | 3FS+1mo | 579d | 65d | start no earlier than 2024-11-01 |
| 10 | 1.4.2 | Začátek prací na staveništi / Construction site works starts | milestone | 0d | 2025-02-28 | 2025-02-28 | 6FS+2mo, 9FS+1mo | 514d | 0d | start no earlier than 2025-02-28 |
| 11 | 1.5 | **Stavební a montážní práce / Construction & Installation works** |  | 474d | 2025-02-28 | 2026-12-23 |  | 522d | 0d |  |
| 12 | 1.5.1 | Stavební a montážní práce / Construction & Installation works |  | 347d | 2025-02-28 | 2026-06-29 | 10 | 514d |  |  |
| 13 | 1.5.2 | Plynová turbína na stavbě / Gas turbine on the site |  | 65d | 2026-01-15 | 2026-04-15 |  | 387d | 0d | finish no earlier than 2026-04-15 |
| 14 | 1.5.3 | Montáž a najetí plynové turbíny / Installation & Commissioning GT |  | 113d | 2026-04-16 | 2026-09-21 | 13 | 387d | 0d | finish no earlier than 2026-07-02 |
| 15 | 1.5.4 | Individuální zkoušky |  | 67d | 2026-09-22 | 2026-12-23 | 14 | 387d |  |  |
| 16 | 1.6 | Uvádění do Provozu / Commissioning |  | 75d | 2026-12-24 | 2027-04-07 | 11 | 387d | 0d |  |
| 17 | 1.7 | Předběžné převzetí / Preliminary acceptance PAC | milestone | 0d | 2027-04-07 | 2027-04-07 | 16 | 387d |  |  |
| 18 | 1.8 | Konečné převzetí / Final acceptance FAC | milestone | 0d | 2029-04-09 | 2029-04-09 | 17 | 0d |  | start no earlier than 2029-04-09 |
